# Gant

How a schedule from MS Project changed from version to version. A marks actual dates.

## Version 1 (saved 2005-02-14, file Gant.mpp)

| ID | WBS | Task | Duration | Start | Finish | Predecessors | Total float | Constraint |
| --- | --- | --- | --- | --- | --- | --- | --- | --- |
| 1 | 1 | **ROMP Project** | 80d? | 2005-01-10 | 2005-04-29 |  | 0d |  |
| 2 | 1.1 | **Web Interface Implementation** | 28d? | 2005-01-10 | 2005-02-16 |  | 0d |  |
| 3 | 1.1.1 | **Controls Implementation** | 27d | 2005-01-10 | 2005-02-15 |  | 0d |  |
| 4 | 1.1.1.1 | **Pan Control** | 5d | 2005-01-10 | 2005-01-14 |  | 0d |  |
| 5 |  | Pan Control Implementation | 4d | 2005-01-10 | 2005-01-13 |  | 0d | start no earlier than 2005-01-10 |
| 6 |  | Pan Control Testing | 1d | 2005-01-14 | 2005-01-14 | 5 | 0d | start no earlier than 2005-01-11 |
| 7 | 1.1.1.2 | **Tilt Control** | 11d | 2005-01-17 | 2005-01-31 | 6 | 0d |  |
| 8 |  | Tilt Control Implementation | 7d | 2005-01-17 | 2005-01-25 |  | 0d |  |
| 9 |  | Tilt Control Testing | 4d | 2005-01-26 | 2005-01-31 | 8 | 0d |  |
| 10 | 1.1.1.3 | **Zoom Control** | 11d | 2005-02-01 | 2005-02-15 | 9 | 0d |  |
| 11 |  | Zoom Control Implementation | 7d | 2005-02-01 | 2005-02-09 |  | 0d | start no earlier than 2005-01-29 |
| 12 |  | Zoom Control Testing | 4d | 2005-02-10 | 2005-02-15 | 11 | 0d |  |
| 13 | 1.1.2 | **Code Review** | 1d? | 2005-02-16 | 2005-02-16 | 3 | 0d |  |
| 14 |  | Controls Implementation Code Review | 1d? | 2005-02-16 | 2005-02-16 |  | 0d |  |
| 15 | 1.1.3 | **Mapping Implementation** | 27d | 2005-01-10 | 2005-02-15 |  | 0d |  |
| 16 | 1.1.3.1 | **Map Class Implementation** | 24d | 2005-01-10 | 2005-02-10 |  | 3d |  |
| 17 |  | Canvas Graphics Implementation | 7d | 2005-01-10 | 2005-01-18 |  | 3d | start no earlier than 2005-01-10 |
| 18 |  | Canvas Graphics Testing | 5d | 2005-01-19 | 2005-01-25 | 17 | 3d |  |
| 19 |  | Mapping Zoom Implementation | 7d | 2005-01-26 | 2005-02-03 | 18 | 3d |  |
| 20 |  | Mapping Zoom Testing | 5d | 2005-02-04 | 2005-02-10 | 19 | 3d |  |
| 21 | 1.1.3.2 | **Robot Class Implementation** | 3d | 2005-02-11 | 2005-02-15 |  | 0d |  |
| 22 |  | Rotation Implementation | 1d | 2005-02-11 | 2005-02-11 |  | 0d | start no earlier than 2005-02-11 |
| 23 |  | Location Implementation | 1d | 2005-02-14 | 2005-02-14 | 22 | 0d |  |
| 24 |  | Robot Class Testing | 1d | 2005-02-15 | 2005-02-15 | 23 | 0d |  |
| 25 | 1.1.4 | **Code Review** | 1d? | 2005-02-16 | 2005-02-16 | 15 | 0d |  |
| 26 |  | Mapping Implementation Code Review | 1d? | 2005-02-16 | 2005-02-16 |  | 0d |  |
| 27 | 1.2 | **Middleman Server Modifications** | 27d | 2005-01-10 | 2005-02-15 |  | 52d |  |
| 28 | 1.2.1 | **Dummy Robot Emulation Server** | 8d | 2005-01-10 | 2005-01-19 |  | 71d |  |
| 29 |  | Dummy Emulation Server Implementation | 4d | 2005-01-10 | 2005-01-13 |  | 71d | start no earlier than 2005-01-10 |
| 30 |  | Dummy Emulation Server Testing | 4d | 2005-01-14 | 2005-01-19 | 29 | 71d |  |
| 31 | 1.2.2 | **Middleman Command Processing** | 19d | 2005-01-20 | 2005-02-15 |  | 52d |  |
| 32 |  | Middleman Command Validation Imp | 4d | 2005-01-20 | 2005-01-25 |  | 52d | start no earlier than 2005-01-20 |
| 33 |  | Middleman Command Validation Testing | 4d | 2005-01-26 | 2005-01-31 | 32 | 52d |  |
| 34 |  | Middleman Robot Position Polling Imp | 4d | 2005-02-01 | 2005-02-04 | 33 | 52d |  |
| 35 |  | Middleman Robot Position Polling Testing | 2d | 2005-02-07 | 2005-02-08 | 34 | 52d |  |
| 36 |  | Middleman Command and Position Integration Testing | 5d | 2005-02-09 | 2005-02-15 | 35 | 52d |  |
| 37 | 1.3 | **Code Review** | 1d? | 2005-02-16 | 2005-02-16 | 27 | 52d |  |
| 38 |  | Middleman Server Mod Code Review | 1d? | 2005-02-16 | 2005-02-16 |  | 52d |  |
| 39 | 1.4 | **Web Interface Integration Testing** | 14d | 2005-02-17 | 2005-03-08 | 2 | 0d |  |
| 40 |  | Controls and Mapping to Applet Integration Testing | 7d | 2005-02-17 | 2005-02-25 |  | 0d |  |
| 41 |  | Applet to Middleman Integration Testing | 7d | 2005-02-28 | 2005-03-08 | 40 | 0d |  |
| 42 | 1.5 | **Middleman Integration Testing** | 7d | 2005-03-09 | 2005-03-17 | 39 | 31d |  |
| 43 |  | Middleman to Robot Integration Testing | 7d | 2005-03-09 | 2005-03-17 |  | 31d |  |
| 44 | 1.6 | **Aria** | 25d | 2005-01-10 | 2005-02-11 |  | 55d |  |
| 45 |  | Installation | 7d | 2005-01-10 | 2005-01-18 |  | 55d | start no earlier than 2005-01-10 |
| 46 |  | API Implementation | 9d | 2005-01-19 | 2005-01-31 | 45 | 55d |  |
| 47 |  | API testing | 9d | 2005-02-01 | 2005-02-11 | 46 | 55d |  |
| 48 | 1.7 | **Usability Testing** | 21d | 2005-03-09 | 2005-04-06 | 39 | 0d |  |
| 49 |  | User Interface Prototype | 21d | 2005-03-09 | 2005-04-06 |  | 0d |  |
| 50 |  | Web interface usability testing | 21d | 2005-03-09 | 2005-04-06 |  | 0d |  |
| 51 | 1.8 | **Documentation** | 76d | 2005-01-10 | 2005-04-25 |  | 4d |  |
| 52 |  | Bi-Weekly Documentation updates | 76d | 2005-01-10 | 2005-04-25 |  | 4d | start no earlier than 2005-01-10 |
| 53 |  | Weekly Website Update | 76d | 2005-01-10 | 2005-04-25 |  | 4d | start no earlier than 2005-01-10 |
| 54 | 1.9 | **Installation** | 2d? | 2005-04-07 | 2005-04-08 | 48 | 0d |  |
| 55 |  | Middleman Server Installation | 2d | 2005-04-07 | 2005-04-08 |  | 0d |  |
| 56 |  | Applet Installation | 1d? | 2005-04-07 | 2005-04-07 |  | 1d |  |
| 57 |  | Buffer Time | 15d | 2005-04-11 | 2005-04-29 | 54 | 0d |  |

## Version 2 (saved 2005-03-24, file Gant3.mpp)

Last finish 2005-04-29 → 2005-05-06 (+7d). Complete tasks 0 → 28.

Added:

| ID | Task | Duration | Start | Finish | Constraint |
| --- | --- | --- | --- | --- | --- |
| 59 | **Video Streaming Design & Implementation** | 39d? | 2005-03-07 A | 2005-04-28 |  |
| 60 | **Video Streaming Design** | 12d? | 2005-03-07 A | 2005-03-22 A |  |
| 61 | MiddleMan Design | 6d? | 2005-03-07 A | 2005-03-14 A | finish no earlier than 2005-03-14 |
| 62 | Applet Design | 7d? | 2005-03-14 A | 2005-03-22 A | start no earlier than 2005-03-14 |
| 63 | **Video Streaming Implementation** | 14d? | 2005-03-24 | 2005-04-12 |  |
| 64 | MiddleMan Implementation | 8d? | 2005-03-24 | 2005-04-04 | start no earlier than 2005-03-24 |
| 65 | Applet Implementation | 7d? | 2005-04-04 | 2005-04-12 | finish no earlier than 2005-04-12 |
| 66 | **Video Streaming Integration & Testing** | 13d? | 2005-04-12 | 2005-04-28 |  |
| 67 | Camera to MiddleMan Testing | 6d? | 2005-04-12 | 2005-04-19 | finish no earlier than 2005-04-19 |
| 68 | MiddleMan to Applet Testing | 7d? | 2005-04-20 | 2005-04-28 |  |

Changed:

| ID | Task | Start | Finish | Duration | Complete | Total float | Other |
| --- | --- | --- | --- | --- | --- | --- | --- |
| 1 | **ROMP Project** | 2005-01-10 A | 2005-04-29 → 2005-05-06 (+7d) | 80d? → 86d? | 0% → 69% |  |  |
| 2 | **Web Interface Implementation** | 2005-01-10 A | 2005-02-16 → 2005-02-25 (+9d) | 28d? → 35d? | 0% → 99% |  |  |
| 3 | **Controls Implementation** | 2005-01-10 A | 2005-02-15 → 2005-02-23 A (+8d) | 27d → 33d | 0% → 100% | 0d → none |  |
| 4 | **Pan Control** | 2005-01-10 A | 2005-01-14 → 2005-01-24 A (+10d) | 5d → 11d | 0% → 100% | 0d → none |  |
| 5 | Pan Control Implementation | 2005-01-10 A | 2005-01-13 → 2005-01-18 A (+5d) | 4d → 7d | 0% → 100% | 0d → none |  |
| 6 | Pan Control Testing | 2005-01-14 → 2005-01-19 A (+5d) | 2005-01-14 → 2005-01-24 A (+10d) | 1d → 4d | 0% → 100% | 0d → none |  |
| 7 | **Tilt Control** | 2005-01-17 → 2005-01-25 A (+8d) | 2005-01-31 → 2005-02-08 A (+8d) |  | 0% → 100% | 0d → none |  |
| 8 | Tilt Control Implementation | 2005-01-17 → 2005-01-25 A (+8d) | 2005-01-25 → 2005-02-02 A (+8d) |  | 0% → 100% | 0d → none |  |
| 9 | Tilt Control Testing | 2005-01-26 → 2005-02-03 A (+8d) | 2005-01-31 → 2005-02-08 A (+8d) |  | 0% → 100% | 0d → none |  |
| 10 | **Zoom Control** | 2005-02-01 → 2005-02-09 A (+8d) | 2005-02-15 → 2005-02-23 A (+8d) |  | 0% → 100% | 0d → none |  |
| 11 | Zoom Control Implementation | 2005-02-01 → 2005-02-09 A (+8d) | 2005-02-09 → 2005-02-17 A (+8d) |  | 0% → 100% | 0d → none |  |
| 12 | Zoom Control Testing | 2005-02-10 → 2005-02-18 A (+8d) | 2005-02-15 → 2005-02-23 A (+8d) |  | 0% → 100% | 0d → none |  |
| 13 | **Code Review** | 2005-02-16 → 2005-02-24 A (+8d) | 2005-02-16 → 2005-02-24 A (+8d) |  | 0% → 100% | 0d → none |  |
| 14 | Controls Implementation Code Review | 2005-02-16 → 2005-02-24 A (+8d) | 2005-02-16 → 2005-02-24 A (+8d) |  | 0% → 100% | 0d → none |  |
| 15 | **Mapping Implementation** | 2005-01-10 A | 2005-02-15 → 2005-02-24 (+9d) | 27d → 34d | 0% → 99% |  |  |
| 16 | **Map Class Implementation** | 2005-01-10 A | 2005-02-10 → 2005-02-16 A (+6d) | 24d → 28d | 0% → 100% | 3d → none |  |
| 17 | Canvas Graphics Implementation | 2005-01-10 A | 2005-01-18 → 2005-01-13 A (-5d) | 7d → 4d | 0% → 100% | 3d → none |  |
| 18 | Canvas Graphics Testing | 2005-01-19 → 2005-01-14 A (-5d) | 2005-01-25 → 2005-01-20 A (-5d) |  | 0% → 100% | 3d → none |  |
| 19 | Mapping Zoom Implementation | 2005-01-26 → 2005-01-21 A (-5d) | 2005-02-03 → 2005-02-09 A (+6d) | 7d → 14d | 0% → 100% | 3d → none |  |
| 20 | Mapping Zoom Testing | 2005-02-04 → 2005-02-10 A (+6d) | 2005-02-10 → 2005-02-16 A (+6d) |  | 0% → 100% | 3d → none |  |
| 21 | **Robot Class Implementation** | 2005-02-11 A | 2005-02-15 → 2005-02-24 A (+9d) | 3d → 10d | 0% → 100% | 0d → none |  |
| 22 | Rotation Implementation | 2005-02-11 A | 2005-02-11 → 2005-02-16 A (+5d) | 1d → 4d | 0% → 100% | 0d → none |  |
| 23 | Location Implementation | 2005-02-14 → 2005-02-17 A (+3d) | 2005-02-14 → 2005-02-22 A (+8d) | 1d → 4d | 0% → 100% | 0d → none |  |
| 24 | Robot Class Testing | 2005-02-15 → 2005-02-23 A (+8d) | 2005-02-15 → 2005-02-24 A (+9d) | 1d → 2d | 0% → 100% | 0d → none |  |
| 25 | **Code Review** | 2005-02-16 → 2005-02-25 A (+9d) | 2005-02-16 → 2005-02-25 A (+9d) |  | 0% → 100% | 0d → none |  |
| 26 | Mapping Implementation Code Review | 2005-02-16 → 2005-02-25 A (+9d) | 2005-02-16 → 2005-02-25 A (+9d) |  | 0% → 100% | 0d → none |  |
| 27 | **Middleman Server Modifications** | 2005-01-10 A | 2005-02-15 → 2005-03-04 A (+17d) | 27d → 40d | 0% → 100% | 52d → none |  |
| 28 | **Dummy Robot Emulation Server** | 2005-01-10 A | 2005-01-19 A |  | 0% → 100% | 71d → none |  |
| 29 | Dummy Emulation Server Implementation | 2005-01-10 A | 2005-01-13 A |  | 0% → 100% | 71d → none |  |
| 30 | Dummy Emulation Server Testing | 2005-01-14 A | 2005-01-19 A |  | 0% → 100% | 71d → none |  |
| 31 | **Middleman Command Processing** | 2005-01-20 A | 2005-02-15 → 2005-03-04 A (+17d) | 19d → 32d | 0% → 100% | 52d → none |  |
| 32 | Middleman Command Validation Imp | 2005-01-20 A | 2005-01-25 → 2005-01-28 A (+3d) | 4d → 7d | 0% → 100% | 52d → none |  |
| 33 | Middleman Command Validation Testing | 2005-01-26 → 2005-01-31 A (+5d) | 2005-01-31 → 2005-02-08 A (+8d) | 4d → 7d | 0% → 100% | 52d → none |  |
| 34 | Middleman Robot Position Polling Imp | 2005-02-01 → 2005-02-09 A (+8d) | 2005-02-04 → 2005-02-17 A (+13d) | 4d → 7d | 0% → 100% | 52d → none |  |
| 35 | Middleman Robot Position Polling Testing | 2005-02-07 → 2005-02-18 A (+11d) | 2005-02-08 → 2005-02-23 A (+15d) | 2d → 4d | 0% → 100% | 52d → none |  |
| 36 | Middleman Command and Position Integration Testing | 2005-02-09 → 2005-02-24 A (+15d) | 2005-02-15 → 2005-03-04 A (+17d) | 5d → 7d | 0% → 100% | 52d → none |  |
| 37 | **Code Review** | 2005-02-16 → 2005-03-07 (+19d) | 2005-02-16 → 2005-03-07 (+19d) |  |  | 52d → 45d |  |
| 38 | Middleman Server Mod Code Review | 2005-02-16 → 2005-03-07 (+19d) | 2005-02-16 → 2005-03-07 (+19d) |  |  | 52d → 45d |  |
| 39 | **Web Interface Integration Testing** | 2005-02-17 → 2005-02-28 A (+11d) | 2005-03-08 → 2005-03-17 A (+9d) |  | 0% → 100% | 0d → none |  |
| 40 | Controls and Mapping to Applet Integration Testing | 2005-02-17 → 2005-02-28 A (+11d) | 2005-02-25 → 2005-03-08 A (+11d) |  | 0% → 100% | 0d → none |  |
| 41 | Applet to Middleman Integration Testing | 2005-02-28 → 2005-03-09 A (+9d) | 2005-03-08 → 2005-03-17 A (+9d) |  | 0% → 100% | 0d → none |  |
| 42 | **Middleman Integration Testing** | 2005-03-09 → 2005-03-18 (+9d) | 2005-03-17 → 2005-03-28 (+11d) |  |  | 31d → 30d |  |
| 43 | Middleman to Robot Integration Testing | 2005-03-09 → 2005-03-18 (+9d) | 2005-03-17 → 2005-03-28 (+11d) |  |  | 31d → 30d |  |
| 44 | **Aria** |  | 2005-02-11 → 2005-02-25 (+14d) | 25d → 35d |  | 55d → 51d |  |
| 46 | API Implementation |  | 2005-01-31 → 2005-02-07 (+7d) | 9d → 14d |  | 55d → 51d |  |
| 47 | API testing | 2005-02-01 → 2005-02-08 (+7d) | 2005-02-11 → 2005-02-25 (+14d) | 9d → 14d |  | 55d → 51d |  |
| 48 | **Usability Testing** | 2005-03-09 → 2005-03-18 A (+9d) | 2005-04-06 → 2005-04-07 (+1d) | 21d → 15d | 0% → 30% | 0d → 22d |  |
| 49 | User Interface Prototype | 2005-03-09 → 2005-03-18 A (+9d) | 2005-04-06 → 2005-04-07 (+1d) | 21d → 15d | 0% → 42% | 0d → 22d | constraint none → start no earlier than 2005-03-17 |
| 50 | Web interface usability testing | 2005-03-09 → 2005-03-25 A (+16d) | 2005-04-06 → 2005-04-07 (+1d) | 21d → 10d | 0% → 13% | 0d → 22d | constraint none → finish no earlier than 2005-04-07 |
| 51 | **Documentation** | 2005-01-10 A | 2005-04-25 → 2005-05-06 (+11d) | 76d → 86d | 0% → 75% | 4d → 0d |  |
| 52 | Bi-Weekly Documentation updates | 2005-01-10 A | 2005-04-25 → 2005-05-06 (+11d) | 76d → 86d | 0% → 75% | 4d → 0d |  |
| 53 | Weekly Website Update | 2005-01-10 A | 2005-04-25 → 2005-05-06 (+11d) | 76d → 86d | 0% → 75% | 4d → 0d |  |
| 54 | **Installation** | 2005-04-07 → 2005-04-08 A (+1d) | 2005-04-08 → 2005-04-11 A (+3d) |  | 0% → 100% | 0d → none |  |
| 55 | Middleman Server Installation | 2005-04-07 → 2005-04-08 A (+1d) | 2005-04-08 → 2005-04-11 A (+3d) |  | 0% → 100% | 0d → none |  |
| 56 | Applet Installation | 2005-04-07 → 2005-04-08 A (+1d) | 2005-04-07 → 2005-04-08 A (+1d) |  | 0% → 100% | 1d → none |  |
| 57 | Buffer Time | 2005-04-11 → 2005-04-12 (+1d) | 2005-04-29 → 2005-05-01 (+2d) |  |  | 0d → 5d |  |
